| id | name | startDate | endDate | priority | barScale | progress | type | parentId |
| --- | --- | --- | --- | --- | --- | --- | --- | --- |
| 1 | Κυκλοφορία λογισμικού | 2026-06-01T00:00:00.000Z | 2026-10-19T00:00:00.000Z | medium | 1 | 0 | group |  |
| 2 | Πάγωμα λειτουργιών | 2026-06-01T00:00:00.000Z | 2026-06-02T00:00:00.000Z | high | 1 | 0 | milestone | 1 |
| 3 | Δοκιμές απόδοσης | 2026-06-02T00:00:00.000Z | 2026-06-16T00:00:00.000Z | medium | 1 | 0 | task | 1 |
| 4 | Ρύθμιση παρατηρησιμότητας | 2026-06-08T00:00:00.000Z | 2026-06-22T00:00:00.000Z | medium | 1 | 0 | task | 1 |
| 5 | Εσωτερικός έλεγχος ασφάλειας | 2026-06-08T00:00:00.000Z | 2026-06-22T00:00:00.000Z | medium | 1 | 0 | task | 1 |
| 6 | Περιβάλλον beta | 2026-06-15T00:00:00.000Z | 2026-06-22T00:00:00.000Z | medium | 1 | 0 | task | 1 |
| 7 | Ένταξη ομάδας beta | 2026-06-29T00:00:00.000Z | 2026-07-13T00:00:00.000Z | medium | 1 | 0 | task | 1 |
| 8 | Beta σε λειτουργία | 2026-07-06T00:00:00.000Z | 2026-08-17T00:00:00.000Z | medium | 1 | 0 | task | 1 |
| 9 | Καθημερινή διαλογή σφαλμάτων | 2026-07-06T00:00:00.000Z | 2026-08-17T00:00:00.000Z | medium | 1 | 0 | task | 1 |
| 10 | Συγκέντρωση μαρτυριών | 2026-07-27T00:00:00.000Z | 2026-08-17T00:00:00.000Z | medium | 1 | 0 | task | 1 |
| 11 | Εξωτερικό penetration test | 2026-07-13T00:00:00.000Z | 2026-08-03T00:00:00.000Z | high | 1 | 0 | task | 1 |
| 12 | Έλεγχος GDPR/CCPA | 2026-07-20T00:00:00.000Z | 2026-08-03T00:00:00.000Z | medium | 1 | 0 | task | 1 |
| 13 | Έλεγχος προσβασιμότητας | 2026-07-27T00:00:00.000Z | 2026-08-10T00:00:00.000Z | medium | 1 | 0 | task | 1 |
| 14 | Διόρθωση ευρημάτων συμμόρφωσης | 2026-08-03T00:00:00.000Z | 2026-08-24T00:00:00.000Z | medium | 1 | 0 | task | 1 |
| 15 | Περιβάλλον επίδειξης πωλήσεων | 2026-08-17T00:00:00.000Z | 2026-08-24T00:00:00.000Z | medium | 1 | 0 | task | 1 |
| 16 | Εκπαίδευση πωλήσεων | 2026-08-24T00:00:00.000Z | 2026-09-07T00:00:00.000Z | high | 1 | 0 | task | 1 |
| 17 | Εκπαίδευση ομάδας υποστήριξης | 2026-08-24T00:00:00.000Z | 2026-09-07T00:00:00.000Z | medium | 1 | 0 | task | 1 |
| 18 | Άρθρα κέντρου υποστήριξης | 2026-08-24T00:00:00.000Z | 2026-09-14T00:00:00.000Z | medium | 1 | 0 | task | 1 |
| 19 | Οδηγοί κλιμάκωσης | 2026-08-31T00:00:00.000Z | 2026-09-07T00:00:00.000Z | medium | 1 | 0 | task | 1 |
| 20 | Σελίδες προσγείωσης και τιμών | 2026-08-31T00:00:00.000Z | 2026-09-14T00:00:00.000Z | medium | 1 | 0 | task | 1 |
| 21 | Βίντεο επίδειξης | 2026-08-31T00:00:00.000Z | 2026-09-21T00:00:00.000Z | medium | 1 | 0 | task | 1 |
| 22 | Άρθρο κυκλοφορίας στο blog | 2026-09-07T00:00:00.000Z | 2026-09-21T00:00:00.000Z | medium | 1 | 0 | task | 1 |
| 23 | Ακολουθία email | 2026-09-14T00:00:00.000Z | 2026-09-21T00:00:00.000Z | medium | 1 | 0 | task | 1 |
| 24 | Προτάσεις προς Τύπο υπό embargo | 2026-09-14T00:00:00.000Z | 2026-09-28T00:00:00.000Z | medium | 1 | 0 | task | 1 |
| 25 | Ήπια κυκλοφορία σε πελάτες | 2026-09-14T00:00:00.000Z | 2026-09-21T00:00:00.000Z | high | 1 | 0 | task | 1 |
| 26 | Δημόσια κυκλοφορία | 2026-09-21T00:00:00.000Z | 2026-09-22T00:00:00.000Z | high | 1 | 0 | milestone | 1 |
| 27 | Αίθουσα κρίσης (48 ώρες) | 2026-09-21T00:00:00.000Z | 2026-09-23T00:00:00.000Z | medium | 1 | 0 | task | 1 |
| 28 | Καθημερινές μετρικές (30 ημέρες) | 2026-09-21T00:00:00.000Z | 2026-10-19T00:00:00.000Z | medium | 1 | 0 | task | 1 |
| 29 | Επικοινωνία επιτυχίας πελατών | 2026-09-21T00:00:00.000Z | 2026-10-12T00:00:00.000Z | medium | 1 | 0 | task | 1 |
| 30 | Αναδρομική ανάλυση μετά την κυκλοφορία | 2026-10-09T00:00:00.000Z | 2026-10-14T00:00:00.000Z | medium | 1 | 0 | task | 1 |
